# Year End Support Pack Project_KickOff

Schedule from MS Project, 2007-10-18 to 2007-12-20.
MIT

## Calendars

- Standard: Mon-Fri 08:00-12:00, 13:00-17:00; Sat-Sun off. Exceptions (off unless hours are given): 2007-11-22 to 2007-11-23, 2007-12-15 08:00-12:00, 13:00-17:00.

## Schedule

| ID | WBS | Task | Type | Duration | Start | Finish | Predecessors | Total slack | Free slack | Constraint |
| --- | --- | --- | --- | --- | --- | --- | --- | --- | --- | --- |
| 1 | 1 | Identify test scenarios |  | 14d | 2007-10-18 | 2007-11-06 |  | 7d | 4d | start no earlier than 2007-10-18 |
| 2 | 2 | Support packs available from SAP including HR SUPPORT PACK | milestone | 0d | 2007-10-18 | 2007-10-18 |  | 38d | 1d | start no earlier than 2007-10-18 |
| 3 | 3 | Apply support packs in SF3, collision reporting |  | 3d | 2007-10-19 | 2007-10-23 | 2 | 37d | 0d | finish no earlier than 2007-10-23 |
| 4 | 4 | Developer validate modifications |  | 3d | 2007-10-24 | 2007-10-26 | 3 | 37d |  |  |
| 5 | 5 | **Apply Support packs in Unit Testing System - SF2** |  | 1d | 2007-10-29 | 2007-10-29 |  | 27d |  |  |
| 6 | 5.1 | Action Log Execution ? |  | 1d | 2007-10-29 | 2007-10-29 |  | 27d | 0d | start no earlier than 2007-10-29 |
| 7 | 6 | Unit Testing |  | 5d | 2007-10-30 | 2007-11-05 | 6 | 27d | 0d | start no earlier than 2007-10-25 |
| 8 | 7 | Issue resolution and retesting buffer |  | 4d | 2007-11-06 | 2007-11-09 | 7 | 27d |  |  |
| 9 | 8 | Production Snap Shot | milestone | 0d | 2007-10-31 | 2007-10-31 |  | 35d |  | start no earlier than 2007-10-31 |
| 10 | 9 | Trial Balance? |  | 1d | 2007-10-31 | 2007-10-31 |  | 34d |  | start no earlier than 2007-10-31 |
| 11 | 10 | **Refresh Regression System and Apply Support packs** |  | 9d | 2007-10-31 | 2007-11-12 |  | 3d | 0d |  |
| 12 | 10.1 | Refresh SH2 with PS1 |  | 4d | 2007-10-31 | 2007-11-05 |  | 3d | 0d | finish no earlier than 2007-11-05 |
| 13 | 10.2 | Support packs and oss notes application |  | 2d | 2007-11-06 | 2007-11-07 | 12 | 3d | 0d | finish no earlier than 2007-11-07 |
| 14 | 10.3 | MIT mods |  | 1d | 2007-11-08 | 2007-11-08 | 13 | 3d | 0d |  |
| 15 | 10.4 | Development slowdown starts | milestone | 0d | 2007-11-08 | 2007-11-08 | 14 | 3d | 0d |  |
| 16 | 10.5 | Apply post refresh production transports 11/01-11/08 |  | 1d | 2007-11-09 | 2007-11-09 | 15, 14 | 3d | 0d | start no earlier than 2007-11-08 |
| 17 | 10.6 | Action Log Execution |  | 1d | 2007-11-12 | 2007-11-12 | 16 | 3d |  | start no earlier than 2007-11-09 |
| 18 | 11 | **Regression Test Functional** |  | 15d | 2007-11-13 | 2007-12-05 | 1, 11 | 3d | 0d |  |
| 19 | 11.1 | Extracts to DataWarehouse |  | 1d | 2007-11-13 | 2007-11-13 |  | 3d | 0d | finish no earlier than 2007-11-07 |
| 20 | 11.2 | Payroll Comparison - duration? |  | 3d | 2007-11-14 | 2007-11-16 | 19 | 3d | 0d |  |
| 21 | 11.3 | Financial Close 10/07 ? Necessary? |  | 1d | 2007-11-19 | 2007-11-19 | 20 | 3d | 0d |  |
| 22 | 11.4 | Functional Regression Test |  | 7d | 2007-11-20 | 2007-11-30 | 21 | 3d | 0d | finish no earlier than 2007-11-30 |
| 23 | 11.5 | Accounts Payable integrated testing |  | 1d | 2007-12-03 | 2007-12-03 | 22 | 3d | 0d | start no earlier than 2007-11-13 |
| 24 | 11.6 | Financial Close 11/07 |  | 2d | 2007-12-04 | 2007-12-05 | 23 | 3d |  | finish no earlier than 2007-12-05 |
| 25 | 12 | Issue resolution and retesting buffer |  | 5d | 2007-12-06 | 2007-12-12 | 18 | 3d | 0d | start no earlier than 2007-11-26 |
| 26 | 13 | Regression test completion signoff | milestone | 1d | 2007-12-13 | 2007-12-13 | 25 | 3d | 1d |  |
| 27 | 14 | Open Enrollement Extracts Completed | milestone | 1d | 2007-12-10 | 2007-12-10 |  | 8d |  | start no earlier than 2007-12-10 |
| 28 | 15 | Golive, Cutover |  | 2d | 2007-12-15 | 2007-12-17 | 26 | 2d |  | start no earlier than 2007-12-15 |
| 29 | 16 | First CY08 Payroll (Pension) | milestone | 0d | 2007-12-20 | 2007-12-20 | 28 | 0d |  | start no earlier than 2007-12-20 |
